# HDBP-2

Schedule from MS Project, 2021-05-11 to 2022-01-31.
MBARI

## Calendars

- Standard: Mon-Fri 08:00-12:00, 13:00-17:00; Sat-Sun off.

## Resources

| Resource |
| --- |
| BSC |
| Ed |
| Chad |
| Gene |
| Eric |
| all |

## Schedule

| ID | WBS | Task | Type | Duration | Start | Finish | Predecessors | Total slack | Resources | Work |
| --- | --- | --- | --- | --- | --- | --- | --- | --- | --- | --- |
| 1 | 1 | **BSC approval** |  | 10d | 2021-05-11 | 2021-05-24 |  | 15d | BSC | 80h |
| 2 | 1.1 | overall mechanical |  | 10d | 2021-05-11 | 2021-05-24 |  | 30d |  |  |
| 3 | 1.2 | 2mm radial spacing |  | 10d | 2021-05-11 | 2021-05-24 |  | 30d |  |  |
| 4 | 1.3 | BQ76942 BMS |  | 10d | 2021-05-11 | 2021-05-24 |  | 30d |  |  |
| 5 | 1.4 | 4P no inter-cell fusing |  | 10d | 2021-05-11 | 2021-05-24 |  | 30d |  |  |
| 6 | 2 | **CPF System Engineering** |  | 1d | 2021-05-11 | 2021-05-11 |  | 0d |  | 16h |
| 7 | 2.1 | FMEA | manual | 1d | 2021-05-11 | 2021-05-11 |  |  | Gene; all | 16h |
| 8 | 3 | **BMS** |  | 120d | 2021-05-11 | 2021-10-25 |  | 0d | Ed; Chad | 1920h |
| 9 | 3.1 | **CCA** |  | 60d | 2021-08-03 | 2021-10-25 |  | 0d |  |  |
| 10 | 3.1.1 | Design |  | 20d | 2021-08-03 | 2021-08-30 | 21 | 0d |  |  |
| 11 | 3.1.2 | Review |  | 5d | 2021-08-31 | 2021-09-06 | 10, 1 | 0d |  |  |
| 12 | 3.1.3 | Build |  | 15d | 2021-09-07 | 2021-09-27 | 11 | 0d |  |  |
| 13 | 3.1.4 | Test |  | 20d | 2021-09-28 | 2021-10-25 | 12 | 0d |  |  |
| 14 | 3.2 | Define register settings |  | 10d | 2021-05-11 | 2021-05-24 |  | 110d |  |  |
| 15 | 3.3 | Eval board testing |  | 15d | 2021-05-11 | 2021-05-31 |  | 105d |  |  |
| 16 | 4 | **LHE-HDBP** |  | 60d? | 2021-05-11 | 2021-08-02 |  | 0d | Ed | 480h |
| 17 | 4.1 | Finalize Motor selection | manual | 1d? | 2021-05-11 | 2021-05-11 |  |  |  |  |
| 18 | 4.2 | Design |  | 20d | 2021-05-11 | 2021-06-07 |  | 0d |  |  |
| 19 | 4.3 | Review |  | 5d | 2021-06-08 | 2021-06-14 | 18 | 0d |  |  |
| 20 | 4.4 | Build |  | 15d | 2021-06-15 | 2021-07-05 | 19, 1 | 0d |  |  |
| 21 | 4.5 | Test |  | 20d | 2021-07-06 | 2021-08-02 | 20 | 0d |  |  |
| 22 | 5 | **Charger** |  | 70d? | 2021-10-26 | 2022-01-31 |  | 0d | Ed; Gene | 1120h |
| 23 | 5.1 | Prototype new/risky elements (I2C driver, Labview to BQ76942 comms, NI USB to I2C module) | manual | 1d? | 2021-10-26 | 2021-10-26 |  |  |  |  |
| 24 | 5.2 | **Design** |  | 30d | 2021-10-26 | 2021-12-06 |  | 0d |  |  |
| 25 | 5.2.1 | Electrical | manual | 20d | 2021-10-26 | 2021-11-22 | 8 |  |  |  |
| 26 | 5.2.2 | Labview VI | manual | 30d | 2021-10-26 | 2021-12-06 | 8 |  |  |  |
| 27 | 5.3 | Review |  | 5d | 2021-12-07 | 2021-12-13 | 24, 1 | 0d |  |  |
| 28 | 5.4 | Build |  | 15d | 2021-12-14 | 2022-01-03 | 27 | 0d |  |  |
| 29 | 5.5 | Test |  | 20d | 2022-01-04 | 2022-01-31 | 28 | 0d |  |  |

| ID | WBS | Task | Type | Duration | Start | Finish | Predecessors | Total slack | Resources | Work |
| --- | --- | --- | --- | --- | --- | --- | --- | --- | --- | --- |
| 30 | 6 | **Embedded Software** |  | 1d? | 2021-05-11 | 2021-05-11 | 24 | 0d | Eric; Gene | 16h |
| 31 | 6.1 | BQ76942 Unit test | manual | 1d? | 2021-05-11 | 2021-05-11 |  |  |  |  |
| 32 | 7 | **Mechanical** |  | 1d? | 2021-05-11 | 2021-05-11 |  | 0d |  |  |
| 33 | 7.1 | Thermal mock up | manual | 1d? | 2021-05-11 | 2021-05-11 |  |  |  |  |
