# HEDPack

Schedule from MS Project, 2021-01-08 to 2021-01-26.
MBARI

## Calendars

- Standard: Mon-Fri 08:00-12:00, 13:00-17:00; Sat-Sun off.

## Resources

| Resource |
| --- |
| Gene |
| Ed |
| Chad |

## Schedule

| ID | WBS | Task | Type | Duration | Start | Finish | Predecessors | Total slack | Free slack | Resources | Work |
| --- | --- | --- | --- | --- | --- | --- | --- | --- | --- | --- | --- |
| 1 | 1 | **CPF High Energy Density Battery Pack** |  | 13d? | 2021-01-08 | 2021-01-26 |  | 0d |  |  | 168h |
| 2 | 1.1 | Requirements Document first draft |  | 1d | 2021-01-08 | 2021-01-08 |  | 0d |  | Gene | 8h |
| 3 | 1.2 | Requirements document final |  | 1d | 2021-01-11 | 2021-01-11 | 2 | 0d |  | Gene; Ed; Chad | 24h |
| 5 | 1.3 | **MBARI design** |  | 7d? | 2021-01-08 | 2021-01-18 |  | 0d |  |  | 64h |
| 6 | 1.3.1 | Finish Mech Design with 2X LHE boards |  | 1d | 2021-01-08 | 2021-01-08 |  | 5d | 0d | Gene | 8h |
| 7 | 1.3.2 | Get a quote | manual | 1d? | 2021-01-11 | 2021-01-11 | 6 |  |  |  |  |
| 8 | 1.3.3 | Survery the market starting with TI parts |  | 1d | 2021-01-12 | 2021-01-12 | 3 | 0d |  | Chad; Ed | 16h |
| 9 | 1.3.4 | Buy an evaluation board |  | 1d | 2021-01-13 | 2021-01-13 | 8 | 0d |  | Chad | 8h |
| 10 | 1.3.5 | Develop test plan |  | 1d | 2021-01-14 | 2021-01-14 | 9 | 0d |  | Chad; Ed | 16h |
| 11 | 1.3.6 | Test |  | 1d | 2021-01-15 | 2021-01-15 | 10 | 0d |  | Chad | 8h |
| 12 | 1.3.7 | Report Results |  | 1d | 2021-01-18 | 2021-01-18 | 11 | 0d |  | Chad | 8h |
| 14 | 1.4 | **Commercial pack** |  | 5d? | 2021-01-08 | 2021-01-14 |  | 4d |  |  | 32h |
| 15 | 1.4.1 | Define solution 1 |  | 1d | 2021-01-12 | 2021-01-12 | 3 | 2d | 0d | Ed | 8h |
| 16 | 1.4.2 | Investigate solution 1 |  | 1d? | 2021-01-13 | 2021-01-13 | 15 | 2d | 0d |  |  |
| 17 | 1.4.3 | Report Results |  | 1d | 2021-01-14 | 2021-01-14 | 16 | 2d |  | Ed | 8h |
| 19 | 1.4.4 | Define Solution 2 |  | 1d | 2021-01-12 | 2021-01-12 | 3 | 2d | 0d | Ed | 8h |
| 20 | 1.4.5 | Investigate solution 2 |  | 1d? | 2021-01-13 | 2021-01-13 | 19 | 2d | 0d |  |  |
| 21 | 1.4.6 | Report Results |  | 1d | 2021-01-14 | 2021-01-14 | 20 | 2d |  | Ed | 8h |
| 23 | 1.5 | Concept Design Review |  | 1d | 2021-01-19 | 2021-01-19 | 12, 17, 21, 7 | 0d |  | Chad; Ed | 16h |
| 24 | 1.6 | Design document |  | 1d | 2021-01-20 | 2021-01-20 | 23 | 0d |  | Gene; Ed; Chad | 24h |
| 26 | 1.7 | Preliminary Design | manual | 1d? | 2021-01-21 | 2021-01-21 | 24 |  |  |  |  |
| 27 | 1.8 | Final Design | manual | 1d? | 2021-01-22 | 2021-01-22 | 26 |  |  |  |  |
| 28 | 1.9 | Build | manual | 1d? | 2021-01-25 | 2021-01-25 | 27 |  |  |  |  |
| 29 | 1.10 | Test | manual | 1d? | 2021-01-26 | 2021-01-26 | 28 |  |  |  |  |
| 30 | 1.11 | Report | manual | 1d? | 2021-01-26 | 2021-01-26 | 29 |  |  |  |  |
